# GPPLAG7V1.0-Plan de proyecto

Schedule from MS Project, 2014-08-15 to 2014-11-24, 6 hours a day, A marks actual dates.

## Calendars

- Copia de Estándar: Mon-Sun 09:00-20:00.

## Resources

| Resource |
| --- |
| Ana Clara E |
| Santiago B |
| Diego S |
| Oscar M |
| Fernando P |
| Juan C |
| Fabricio G |
| Mathias B |
| Mathias F |
| Rolando L |
| Emiliano T |
| Santiago F |
| Ignacio A |

## Schedule

| ID | WBS | Task | Type | Duration | Start | Finish | Predecessors | Complete | Remaining | Total slack | Resources | Work | Actual work |
| --- | --- | --- | --- | --- | --- | --- | --- | --- | --- | --- | --- | --- | --- |
| 1 | 1 | **Fase Inicial** |  | 58.5d | 2014-08-15 A | 2014-09-15 |  | 10% | 52.78d | 0d |  | 687h | 184h |
| 2 | 1.1 | **Iteración 1** |  | 32.83d | 2014-08-15 A | 2014-09-01 |  | 32% | 22.25d | 0d |  | 687h | 184h |
| 3 | 1.1.1 | **Semana 1** |  | 16.5d | 2014-08-15 A | 2014-08-24 |  | 85% | 2.49d | 0d |  | 217h | 173h |
| 4 | 1.1.1.1 | Reunión de Equipo (0) | manual | 2h | 2014-08-15 A | 2014-08-15 A |  | 100% |  |  | Ana Clara E; Diego S; Emiliano T; Fabricio G; Fernando P; Ignacio A; Juan C; Mathias B; Mathias F; Oscar M; Rolando L; Santiago B; Santiago F | 26h | 26h |
| 5 | 1.1.1.2 | Elaborar acta de reunión de equipo (0) | manual | 1h | 2014-08-15 A | 2014-08-15 A | 4 | 100% |  |  | Ignacio A | 1h | 1h |
| 6 | 1.1.1.3 | Elaborar Plan de iteración 1 (0) | manual | 6h | 2014-08-16 A | 2014-08-16 A |  | 100% |  |  | Ignacio A | 4h | 4h |
| 7 | 1.1.1.4 | Entrega 0 | milestone, manual | 0d | 2014-08-17 A | 2014-08-17 A | 4, 5, 6 | 100% |  |  |  |  |  |
| 8 | 1.1.1.5 | Probar tecnologías PostGIS, GeoServer | manual | 6d | 2014-08-15 A | 2014-08-18 |  | 75% | 1.5d |  | Mathias B; Mathias F; Rolando L; Santiago F | 44h | 24h |
| 9 | 1.1.1.6 | Reunión de Requerimientos (1) | manual | 1h | 2014-08-18 A | 2014-08-18 A |  | 100% |  |  | Ana Clara E; Diego S; Emiliano T; Fabricio G; Fernando P; Ignacio A; Juan C; Mathias B; Mathias F; Oscar M; Rolando L; Santiago B; Santiago F | 13h | 13h |
| 10 | 1.1.1.7 | Elaborar acta de reunión de requerimientos (1) | manual | 2h | 2014-08-18 A | 2014-08-18 A | 9 | 100% |  |  | Ana Clara E; Fabricio G; Juan C; Santiago B | 8h | 8h |
| 11 | 1.1.1.8 | Especificar requerimientos (1) | manual | 8h | 2014-08-19 A | 2014-08-19 A | 13 | 100% |  |  | Ana Clara E; Fabricio G; Juan C; Santiago B | 24h | 24h |
| 12 | 1.1.1.9 | Reunión de Requerimientos (1) | manual | 1h | 2014-08-19 A | 2014-08-19 A | 9 | 100% |  |  | Ana Clara E; Fabricio G; Juan C; Santiago B; Diego S; Fernando P; Ignacio A; Oscar M | 8h | 8h |
| 13 | 1.1.1.10 | Elaborar acta de reunión de requerimientos (1) | manual | 1h | 2014-08-19 A | 2014-08-19 A | 10, 12 | 100% |  |  | Ana Clara E; Fabricio G; Juan C; Santiago B | 4h | 4h |
| 14 | 1.1.1.11 | Elaborar documento informativo(1) | manual | 1h | 2014-08-19 A | 2014-08-19 A | 23 | 100% |  |  | Ignacio A | 1h | 1h |
| 15 | 1.1.1.12 | Definir Glosario (1) | manual | 4h | 2014-08-20 A | 2014-08-20 A | 11 | 100% |  |  | Ana Clara E; Fabricio G; Juan C; Santiago B | 8h | 8h |
| 16 | 1.1.1.13 | Elaborar informe de situación de proyecto (1) | manual | 7h | 2014-08-18 A | 2014-08-19 A | 20 | 100% |  |  | Ignacio A | 6h | 6h |
| 17 | 1.1.1.14 | Elaborar modelo de dominio (1) | manual | 6h | 2014-08-20 A | 2014-08-20 A | 11 | 100% |  |  | Ana Clara E; Fabricio G; Juan C; Santiago B; Diego S | 20h | 20h |
| 18 | 1.1.1.15 | Modelo de Dominio (1) | milestone, manual | 0d | 2014-08-21 A | 2014-08-21 A | 17 | 100% |  |  |  |  |  |
| 19 | 1.1.1.16 | Pautas para la interfaz de usuario (1) | manual | 1d | 2014-08-18 A | 2014-08-18 A |  | 100% |  |  | Juan C; Fabricio G | 8h | 8h |
| 20 | 1.1.1.17 | Registro de actividades (1) | manual | 1h | 2014-08-18 A | 2014-08-18 A |  | 100% |  |  | Ana Clara E; Diego S; Emiliano T; Fabricio G; Fernando P; Ignacio A; Juan C; Mathias B; Mathias F; Oscar M; Rolando L; Santiago B; Santiago F | 13h | 13h |
| 21 | 1.1.1.18 | Especificar Casos de uso (2) | manual | 4h | 2014-08-21 | 2014-08-21 | 10 |  |  |  | Ana Clara E; Fabricio G; Fernando P; Juan C; Oscar M; Santiago B | 24h |  |
| 22 | 1.1.1.19 | Modelo de casos de uso (2) | milestone, manual | 0d | 2014-08-21 | 2014-08-21 | 21 |  |  |  | Ana Clara E; Fabricio G; Fernando P; Juan C; Oscar M; Santiago B |  |  |
| 23 | 1.1.1.20 | Descripción del Proyecto (1) | manual | 4h | 2014-08-18 A | 2014-08-18 A |  | 100% |  |  | Ignacio A | 4h | 4h |
| 24 | 1.1.1.21 | Revisar entregas semana (1) | manual | 1h | 2014-08-22 A | 2014-08-22 A | 13, 11, 14, 15, 16, 18, 19, 20, 22, 23 | 100% |  |  | Oscar M | 1h | 1h |
| 25 | 1.1.1.22 | Entrega 1 | milestone, manual | 0d | 2014-08-24 A | 2014-08-24 A | 24 | 100% |  |  | Ana Clara E; Diego S; Emiliano T; Fabricio G; Fernando P; Ignacio A; Juan C; Mathias B; Mathias F; Oscar M; Rolando L; Santiago B; Santiago F |  |  |

| ID | WBS | Task | Type | Duration | Start | Finish | Predecessors | Complete | Remaining | Total slack | Resources | Work | Actual work |
| --- | --- | --- | --- | --- | --- | --- | --- | --- | --- | --- | --- | --- | --- |
| 26 | 1.1.2 | **Semana 2** |  | 14.5d | 2014-08-25 A | 2014-09-01 |  | 1% | 14.35d | 0d |  | 470h | 11h |
| 27 | 1.1.2.1 | Reunión de Requerimientos (2) | manual | 1h | 2014-08-27 A | 2014-08-27 A | 9 | 100% |  |  | Ana Clara E; Fabricio G; Juan C; Santiago B; Diego S; Fernando P; Ignacio A; Oscar M | 8h | 8h |
| 28 | 1.1.2.2 | Elaborar acta de reunión de requerimientos (2) | manual | 1h | 2014-08-27 | 2014-08-27 | 27, 10 |  |  |  | Ana Clara E; Fabricio G; Juan C; Santiago B | 4h |  |
| 29 | 1.1.2.3 | Especificar requerimientos (2) | manual | 4h | 2014-08-27 | 2014-08-27 | 28 |  |  |  |  |  |  |
| 30 | 1.1.2.4 | Definir Glosario (2) | manual | 2h | 2014-08-27 | 2014-08-27 | 15, 29 |  |  |  | Ana Clara E; Fabricio G; Juan C; Santiago B | 8h |  |
| 31 | 1.1.2.5 | Especificar Casos de uso (2) | manual | 11h | 2014-08-27 | 2014-08-27 | 29 |  |  |  | Ana Clara E; Fabricio G; Fernando P; Juan C; Oscar M; Santiago B | 54h |  |
| 32 | 1.1.2.6 | Modelo de casos de uso (2) | milestone, manual | 0d | 2014-08-27 | 2014-08-27 | 31 |  |  |  |  |  |  |
| 33 | 1.1.2.7 | Priorizar casos de uso (2) | manual | 2h | 2014-08-27 | 2014-08-27 | 32, 22 |  |  |  | Diego S; Fabricio G; Fernando P; Juan C; Oscar M | 10h |  |
| 34 | 1.1.2.8 | Describir Arquitectura (Vista del modelo de casos de uso)(2) | manual | 4h | 2014-08-28 | 2014-08-28 | 33 |  |  |  | Ana Clara E; Diego S; Fabricio G; Juan C; Santiago B | 20h |  |
| 35 | 1.1.2.9 | Descripción de la Arquitectura (Vista del modelo de casos de uso) (2) | milestone, manual | 0d | 2014-08-28 | 2014-08-28 | 34 |  |  |  |  |  |  |
| 36 | 1.1.2.10 | Validación con el cliente (2) | manual | 1h | 2014-08-25 | 2014-08-25 |  |  |  |  | Diego S | 1h |  |
| 37 | 1.1.2.11 | Documento de validación con el cliente (2) | milestone, manual | 0d | 2014-08-25 | 2014-08-25 | 36 |  |  |  | Diego S |  |  |
| 38 | 1.1.2.12 | Modificaciones correspondientes al modelo de dominio (2) | manual | 6h | 2014-08-26 | 2014-08-26 | 18, 29 |  |  |  | Ana Clara E; Fabricio G; Juan C; Santiago B; Diego S | 20h |  |
| 39 | 1.1.2.13 | Modelo de Dominio (2) | milestone, manual | 0d | 2014-08-26 | 2014-08-26 | 38 |  |  |  | Ana Clara E; Fabricio G; Juan C; Santiago B; Diego S |  |  |
| 40 | 1.1.2.14 | Definir Pautas para la Interfaz de usuario (2) | manual | 8h | 2014-08-27 | 2014-08-27 | 28, 32, 22 |  |  |  | Fabricio G; Juan C | 12h |  |
| 41 | 1.1.2.15 | Diseñar casos de uso (2) | manual | 10h | 2014-08-28 | 2014-08-28 | 30, 29, 32, 40, 22 |  |  |  | Ana Clara E; Diego S; Santiago B | 24h |  |
| 42 | 1.1.2.16 | Modelo de diseño (2) | milestone, manual | 0d | 2014-08-29 | 2014-08-29 | 41 |  |  |  | Diego S |  |  |
| 43 | 1.1.2.17 | Describir Arquitectura (Completa) (2) | manual | 8h | 2014-08-28 | 2014-08-28 | 29, 30, 32, 22 |  |  |  | Diego S; Ana Clara E; Fabricio G; Juan C; Santiago B | 30h |  |
| 44 | 1.1.2.18 | Descripción de la arquitectura (Completa) (2) | milestone, manual | 0d | 2014-08-28 | 2014-08-28 | 43 |  |  |  | Diego S |  |  |
| 45 | 1.1.2.19 | Documentar Requerimientos para el prototipo (2) | manual | 6h | 2014-08-27 | 2014-08-27 | 32, 29, 22 |  |  |  | Diego S; Ana Clara E; Fabricio G; Juan C; Santiago B | 20h |  |
| 46 | 1.1.2.20 | Documento de Requerimientos para el prototipo (2) | milestone, manual | 0d | 2014-08-28 | 2014-08-28 | 45 |  |  |  | Diego S |  |  |
| 47 | 1.1.2.21 | Diseñar prototipo (2) | manual | 9h | 2014-08-29 | 2014-08-30 | 46, 42 |  |  |  | Diego S; Mathias B; Mathias F; Rolando L; Santiago F | 40h |  |
| 48 | 1.1.2.22 | Documento de diseño del prototipo (2) | milestone, manual | 0d | 2014-08-31 | 2014-08-31 | 47 |  |  |  | Mathias B; Mathias F; Rolando L; Santiago F |  |  |
| 49 | 1.1.2.23 | Definir estándares de documentación técnica (2) | manual | 4h | 2014-08-25 | 2014-08-25 |  |  |  |  | Mathias B; Mathias F; Rolando L; Santiago F | 16h |  |
| 50 | 1.1.2.24 | Estándar de documentación técnica (2) | milestone, manual | 0d | 2014-08-25 | 2014-08-25 | 49 |  |  |  | Mathias B; Mathias F; Rolando L; Santiago F |  |  |
| 51 | 1.1.2.25 | Estándar de implementación (2) | milestone, manual | 0d | 2014-08-25 | 2014-08-25 | 49 |  |  |  | Mathias B; Mathias F; Rolando L; Santiago F |  |  |
| 52 | 1.1.2.26 | Planificar la verificación (2) | manual | 6h | 2014-08-27 | 2014-08-27 | 29, 32, 22 |  |  |  | Fernando P | 4h |  |
| 53 | 1.1.2.27 | Plan de verificación y validación (2) | milestone, manual | 0d | 2014-08-27 | 2014-08-27 | 52 |  |  |  | Fernando P |  |  |
| 54 | 1.1.2.28 | Definir alcance del sistema (2) | manual | 4h | 2014-08-28 | 2014-08-28 | 29, 30, 32, 40, 22 |  |  |  | Ana Clara E; Diego S; Fabricio G; Ignacio A; Juan C; Santiago B | 24h |  |
| 55 | 1.1.2.29 | Alcance del sistema (2) | milestone, manual | 0d | 2014-08-28 | 2014-08-28 | 54 |  |  |  |  |  |  |
| 56 | 1.1.2.30 | Elaborar plan de desarrollo (2) | manual | 5h | 2014-08-28 | 2014-08-29 | 54, 6 |  |  |  | Diego S | 4h |  |
| 57 | 1.1.2.31 | Plan de desarrollo (2) | milestone, manual | 0d | 2014-08-29 | 2014-08-29 | 56 |  |  |  | Diego S |  |  |
| 58 | 1.1.2.32 | Implementar el prototipo (2) | manual | 22h | 2014-08-29 | 2014-08-31 | 42, 57, 44, 6 |  |  |  | Diego S; Fabricio G; Juan C; Mathias B; Mathias F; Rolando L; Santiago B; Santiago F | 64h |  |
| 59 | 1.1.2.33 | Reunión de responsables por área (2) | manual | 1h | 2014-08-29 | 2014-08-29 |  |  |  |  | Ana Clara E; Diego S; Emiliano T; Fabricio G; Fernando P; Ignacio A; Juan C; Mathias B; Mathias F; Oscar M; Rolando L; Santiago B; Santiago F | 13h |  |
| 60 | 1.1.2.34 | Elaborar plan de iteración 2 (2) | manual | 8h | 2014-08-29 | 2014-08-29 | 59 |  |  |  | Ignacio A | 6h |  |
| 61 | 1.1.2.35 | Elaborar informe de situación de proyecto (2) | manual | 1h | 2014-09-01 A | 2014-09-01 | 57, 60 | 25% | 0.75h |  | Diego S; Ignacio A | 2h | 0.5h |
| 62 | 1.1.2.36 | Estimaciones y mediciones (2) | manual | 1h | 2014-09-01 A | 2014-09-01 | 54, 61, 57 | 8% | 0.92h |  | Ana Clara E; Diego S; Fabricio G; Ignacio A; Juan C; Santiago B | 6h | 0.5h |
| 63 | 1.1.2.37 | Elaborar documento de riesgos (2) | manual | 1h | 2014-09-01 | 2014-09-01 | 62, 61 |  |  |  | Emiliano T; Fabricio G; Fernando P; Ignacio A; Juan C; Mathias B; Mathias F; Oscar M; Rolando L; Santiago B; Santiago F; Ana Clara E; Diego S | 13h |  |
| 64 | 1.1.2.38 | Documento de riesgos (2) | milestone, manual | 0d | 2014-09-01 | 2014-09-01 | 63 |  |  |  | Ignacio A |  |  |
| 65 | 1.1.2.39 | Plan de Calidad (2) | manual | 1h | 2014-08-27 | 2014-08-27 | 28, 29, 32, 22 |  |  |  | Ana Clara E; Oscar M; Santiago B | 3h |  |
| 66 | 1.1.2.40 | Planificar configuración SCM (2) | manual | 2h | 2014-08-25 | 2014-08-25 |  |  |  |  | Emiliano T | 2h |  |
| 67 | 1.1.2.41 | Definir línea base (2) | manual | 2h | 2014-08-25 | 2014-08-25 |  |  |  |  | Emiliano T; Mathias B; Mathias F; Oscar M; Rolando L; Santiago F | 12h |  |
| 68 | 1.1.2.42 | Plan de configuración (2) | milestone | 0d | 2014-08-25 | 2014-08-25 | 66, 67 |  |  | 3.33d |  |  |  |
| 69 | 1.1.2.43 | Planificar el proyecto (2) | manual | 4h | 2014-09-01 | 2014-09-01 | 29, 55, 64, 62, 61, 32, 57, 53, 65, 68, 22 |  |  |  | Ignacio A; Emiliano T; Fernando P; Oscar M | 8h |  |
| 70 | 1.1.2.44 | Plan de proyecto (2) | milestone, manual | 0d | 2014-09-01 | 2014-09-01 | 69 |  |  |  | Ignacio A |  |  |
| 71 | 1.1.2.45 | Reunión de Equipo (2) | manual | 2h | 2014-08-29 A | 2014-08-29 |  | 8% | 1.85h |  | Ana Clara E; Diego S; Emiliano T; Fabricio G; Fernando P; Ignacio A; Juan C; Mathias B; Mathias F; Oscar M; Rolando L; Santiago B; Santiago F | 26h | 2h |
| 72 | 1.1.2.46 | Elaborar acta de reunión de equipo (2) | milestone, manual | 0d | 2014-08-29 | 2014-08-29 | 71 |  |  |  | Ignacio A; Juan C |  |  |
| 73 | 1.1.2.47 | Definir ambiente controlado (2) | manual | 1h | 2014-08-27 A | 2014-08-27 | 68 |  | 1h |  | Emiliano T; Mathias B; Mathias F; Rolando L; Santiago F | 5h |  |
| 74 | 1.1.2.48 | Definir documento de visión (2) | manual | 2h | 2014-08-27 | 2014-08-27 | 28, 29, 32, 23, 22, 76 |  |  |  | Ana Clara E; Fabricio G; Juan C; Santiago B | 8h |  |
| 75 | 1.1.2.49 | Lecciones Aprendidas (2) | manual | 1h | 2014-09-01 | 2014-09-01 | 61, 72 |  |  |  | Ignacio A | 1h |  |
| 76 | 1.1.2.50 | Descripción del Proyecto (2) | manual | 4h | 2014-08-26 | 2014-08-26 | 23, 29 |  |  |  | Ignacio A | 2h |  |
| 77 | 1.1.2.51 | Revisar entregas semana (2) | milestone, manual | 0h | 2014-09-01 | 2014-09-01 | 28, 29, 30, 35, 37, 39, 40, 44, 48, 46, 50, 51, 53, 58, 72, 64, 62, 61, 73, 65, 68, 57, 70, 60, 75, 74, 76 |  |  |  | Oscar M |  |  |
| 78 | 1.1.2.52 | Entrega Semana 2 | milestone, manual | 0d | 2014-09-01 | 2014-09-01 | 77 |  |  |  |  |  |  |

Notes:
- 33: http://www.fing.edu.uy/inco/cursos/ingsoft/pis/memoria/dvd02/experiencia2011/MUM/pluginMetodos/tasks/r4.priorizarCasosUso_9A040FCB.html
- 34: http://www.fing.edu.uy/inco/cursos/ingsoft/pis/memoria/dvd02/experiencia2011/MUM/pluginMetodos/deliveryprocesses/d2.describirArquitectura_4A39C5C0.html?proc=_lVXS4VGKEd6FIfGmpQJeqw&path=_lVXS4VGKEd6FIfGmpQJeqw,_0A4sIVGKEd6FIfGmpQJeqw,_AZLegVGLEd6FIfGmpQJe
- 36: http://www.fing.edu.uy/inco/cursos/ingsoft/pis/memoria/dvd02/experiencia2011/MUM/pluginMetodos/tasks/r5.validacionCliente_A64814D4.html
- 40: http://www.fing.edu.uy/inco/cursos/ingsoft/pis/memoria/dvd02/experiencia2011/MUM/pluginMetodos/tasks/r6.definirPautasInterfazUsuario_6623E117.html
- 41: http://www.fing.edu.uy/inco/cursos/ingsoft/pis/memoria/dvd02/experiencia2011/MUM/pluginMetodos/tasks/d1.disenarCasosUso_AB966D55.html
- 42: http://www.fing.edu.uy/inco/cursos/ingsoft/pis/memoria/dvd02/experiencia2011/MUM/pluginMetodos/workproducts/modeloDiseno_E50AFDE8.html
- 43: http://www.fing.edu.uy/inco/cursos/ingsoft/pis/memoria/dvd02/experiencia2011/MUM/pluginMetodos/tasks/d2.describirArquitectura_86A64863.html
- 45: http://www.fing.edu.uy/inco/cursos/ingsoft/pis/memoria/dvd02/experiencia2011/MUM/pluginMetodos/tasks/r10.documentarRequerimientos_58BF0A39.html
- 47: http://www.fing.edu.uy/inco/cursos/ingsoft/pis/memoria/dvd02/experiencia2011/MUM/pluginMetodos/tasks/d5.disenarPrototipo_9FF60F60.html
- 48: http://www.fing.edu.uy/inco/cursos/ingsoft/pis/memoria/dvd02/experiencia2011/MUM/pluginMetodos/workproducts/documentoDisenoPrototipo_E44B79F6.html
- 49: http://www.fing.edu.uy/inco/cursos/ingsoft/pis/memoria/dvd02/experiencia2011/MUM/pluginMetodos/tasks/i1.definirEstandaresDocumentacionTecnica_F5126C9D.html
- 50: http://www.fing.edu.uy/inco/cursos/ingsoft/pis/memoria/dvd02/experiencia2011/MUM/pluginMetodos/workproducts/estandarDocumentacionTecnica_F6E9D5F1.html
- 51: http://www.fing.edu.uy/inco/cursos/ingsoft/pis/memoria/dvd02/experiencia2011/MUM/pluginMetodos/workproducts/estandarImplementacion_2AF3D3A6.html?nodeId=8fc09fe6
- 52: http://www.fing.edu.uy/inco/cursos/ingsoft/pis/memoria/dvd02/experiencia2011/MUM/pluginMetodos/tasks/v1.planificarVerificacion_3403661D.html
- 54: http://www.fing.edu.uy/inco/cursos/ingsoft/pis/memoria/dvd02/experiencia2011/MUM/pluginMetodos/tasks/r7.definirAlcanceSistema_5C89EA15.html
- 58: http://www.fing.edu.uy/inco/cursos/ingsoft/pis/memoria/dvd02/experiencia2011/MUM/pluginMetodos/tasks/i2.implementarPrototipo_48D411B0.html
- 62: http://www.fing.edu.uy/inco/cursos/ingsoft/pis/memoria/dvd02/experiencia2011/MUM/pluginMetodos/tasks/g3.estimacionesMediciones_C6EFBC54.html
- 63: http://www.fing.edu.uy/inco/cursos/ingsoft/pis/memoria/dvd02/experiencia2011/MUM/pluginMetodos/tasks/g4.gestionRiesgos_68264CB.html
- 66: http://www.fing.edu.uy/inco/cursos/ingsoft/pis/memoria/dvd02/experiencia2011/MUM/pluginMetodos/tasks/c1.planificarConfiguracionSCM_A520CDE0.html
- 67: http://www.fing.edu.uy/inco/cursos/ingsoft/pis/memoria/dvd02/experiencia2011/MUM/pluginMetodos/tasks/c2.definirLineaBaseProyecto_426D6B5B.html
- 69: http://www.fing.edu.uy/inco/cursos/ingsoft/pis/memoria/dvd02/experiencia2011/MUM/pluginMetodos/tasks/g1.planificarProyecto_73EFE8AB.html
- 70: http://www.fing.edu.uy/inco/cursos/ingsoft/pis/memoria/dvd02/experiencia2011/MUM/pluginMetodos/workproducts/planProyecto_D7DA434B.html
- 73: http://www.fing.edu.uy/inco/cursos/ingsoft/pis/memoria/dvd02/experiencia2011/MUM/pluginMetodos/tasks/c4.DefinirAmbienteControlado_5592AFA.html
- 74: http://www.fing.edu.uy/inco/cursos/ingsoft/pis/memoria/dvd02/experiencia2011/MUM/pluginMetodos/workproducts/documentoVision_5EDFAF07.html?nodeId=4520df79
- 75: http://www.fing.edu.uy/inco/cursos/ingsoft/pis/memoria/dvd02/experiencia2011/MUM/pluginMetodos/tasks/g20.gestionLeccionesAprendidas_261DF3E0.html
- 77: http://www.fing.edu.uy/inco/cursos/ingsoft/pis/memoria/dvd02/experiencia2011/MUM/pluginMetodos/workproducts/entregaSemanalSQA_E5B566DC.html?nodeId=3986a8f6

| ID | WBS | Task | Type | Duration | Start | Finish | Total slack |
| --- | --- | --- | --- | --- | --- | --- | --- |
| 79 | 1.2 | **Iteración 2** |  | 25.5d | 2014-09-02 | 2014-09-15 |  |
| 80 | 1.2.1 | **Diseño** |  | 1.83d? | 2014-09-02 | 2014-09-02 |  |
| 81 | 1.2.1.1 | D1 - Diseñar casos de uso | manual | 1.83d? | 2014-09-02 | 2014-09-02 |  |
| 82 | 1.2.1.2 | D2 - Describir la arquitectura | manual | 1.83d? | 2014-09-02 | 2014-09-02 |  |
| 83 | 1.2.1.3 | D3 - Comunicar el diseño a los implementadores | manual | 1.83d? | 2014-09-02 | 2014-09-02 |  |
| 84 | 1.2.1.4 | D4 - Diseñar base de datos | manual | 1.83d? | 2014-09-02 | 2014-09-02 |  |
| 85 | 1.2.2 | **Reuniones de Apoyo** |  | 13d | 2014-09-03 | 2014-09-10 | 0d |
| 86 | 1.2.2.1 | E1.1 - Clase para Administradores | manual | 1h | 2014-09-03 | 2014-09-03 |  |
| 87 | 1.2.2.2 | E1.2 Clase para Arquitectos | manual | 1h | 2014-09-05 | 2014-09-05 |  |
| 88 | 1.2.2.3 | E1.3 Clase para Resp. V&V | manual | 1h | 2014-09-10 | 2014-09-10 |  |
| 89 | 1.2.3 | **Gestión de Calidad** |  | 1.83d? | 2014-09-02 | 2014-09-02 |  |
| 90 | 1.2.3.1 | Q1 - Identificar las propiedades de calidad | manual | 1.83d? | 2014-09-02 | 2014-09-02 |  |
| 91 | 1.2.3.2 | Q2 - Plan de calidad | manual | 1.83d? | 2014-09-02 | 2014-09-02 |  |
| 92 | 1.2.3.3 | Q5 - Revisar las entregas | manual | 1.83d? | 2014-09-02 | 2014-09-02 |  |
| 93 | 1.2.3.4 | Q6 - Revisar el ajuste del proceso | manual | 1.83d? | 2014-09-02 | 2014-09-02 |  |
| 94 | 1.2.3.5 | Q7 - Evaluar la calidad de los productos | manual | 1.83d? | 2014-09-02 | 2014-09-02 |  |
| 95 | 1.2.4 | **Gestión de Configuración** |  | 1.83d? | 2014-09-02 | 2014-09-02 |  |
| 96 | 1.2.4.1 | C1 - Planificar la configuración del SCM | manual | 1.83d? | 2014-09-02 | 2014-09-02 |  |
| 97 | 1.2.4.2 | C2 - Definir la línea base del proyecto | manual | 1.83d? | 2014-09-02 | 2014-09-02 |  |
| 98 | 1.2.4.3 | C4 - Definir el ambiente controlad | manual | 1.83d? | 2014-09-02 | 2014-09-02 |  |
| 99 | 1.2.4.4 | C5 - Control de cambios | manual | 1.83d? | 2014-09-02 | 2014-09-02 |  |
| 100 | 1.2.5 | **Gestión de Proyecto** |  | 1.83d? | 2014-09-02 | 2014-09-02 |  |
| 101 | 1.2.5.1 | G1 - Planificar el proyecto | manual | 1.83d? | 2014-09-02 | 2014-09-02 |  |
| 102 | 1.2.5.2 | G13 - Evaluar la fase | manual | 1.83d? | 2014-09-02 | 2014-09-02 |  |
| 103 | 1.2.5.3 | G15 - Revisión técnica y administrativa | manual | 1.83d? | 2014-09-02 | 2014-09-02 |  |
| 104 | 1.2.5.4 | G16 - Reunión de responsables por área | manual | 1.83d? | 2014-09-02 | 2014-09-02 |  |
| 105 | 1.2.5.5 | G18 - Presentación al director de proyecto | manual | 1.83d? | 2014-09-02 | 2014-09-02 |  |
| 106 | 1.2.5.6 | G2 - Seguimiento del proyecto | manual | 1.83d? | 2014-09-02 | 2014-09-02 |  |
| 107 | 1.2.5.7 | G3 - Estimaciones y mediciones | manual | 1.83d? | 2014-09-02 | 2014-09-02 |  |
| 108 | 1.2.5.8 | G4 - Gestión de riesgo | manual | 1.83d? | 2014-09-02 | 2014-09-02 |  |
| 109 | 1.2.5.9 | G5 - Registrar esfuerzo | manual | 1.83d? | 2014-09-02 | 2014-09-02 |  |
| 110 | 1.2.5.10 | G6 - Reunión de equipo | manual | 1.83d? | 2014-09-02 | 2014-09-02 |  |
| 111 | 1.2.5.11 | G7 - Elaborar Acta de reunión de equipo | manual | 1.83d? | 2014-09-02 | 2014-09-02 |  |
| 112 | 1.2.5.12 | G8 - Reunión de seguimient | manual | 1.83d? | 2014-09-02 | 2014-09-02 |  |
| 113 | 1.2.5.13 | G9 - Ajustar y controlar el desarrollo | manual | 1.83d? | 2014-09-02 | 2014-09-02 |  |

| ID | WBS | Task | Type | Duration | Start | Finish |
| --- | --- | --- | --- | --- | --- | --- |
| 114 | 1.2.6 | **Implementación** |  | 1.83d? | 2014-09-02 | 2014-09-02 |
| 115 | 1.2.6.1 | I1 - Definir estándares de documentación técnica | manual | 1.83d? | 2014-09-02 | 2014-09-02 |
| 116 | 1.2.6.2 | I2 - Implementar el prototipo | manual | 1.83d? | 2014-09-02 | 2014-09-02 |
| 117 | 1.2.6.3 | I3 - Corregir la implementación | manual | 1.83d? | 2014-09-02 | 2014-09-02 |
| 118 | 1.2.6.4 | I4 - Planificar la integración de la iteración | manual | 1.83d? | 2014-09-02 | 2014-09-02 |
| 119 | 1.2.6.5 | I5 - Integrar el sistema (del prototipo) | manual | 1.83d? | 2014-09-02 | 2014-09-02 |
| 120 | 1.2.6.6 | I7 - Verificación unitaria del módulo | manual | 1.83d? | 2014-09-02 | 2014-09-02 |
| 121 | 1.2.7 | **Requerimientos** |  | 1.83d? | 2014-09-02 | 2014-09-02 |
| 122 | 1.2.7.1 | R1 - Reunión de requerimientos | manual | 1.83d? | 2014-09-02 | 2014-09-02 |
| 123 | 1.2.7.2 | R2 - Especificar requerimientos | manual | 1.83d? | 2014-09-02 | 2014-09-02 |
| 124 | 1.2.7.3 | R3 - Especificar casos de uso | manual | 1.83d? | 2014-09-02 | 2014-09-02 |
| 125 | 1.2.7.4 | R4 - Priorizar casos de uso | manual | 1.83d? | 2014-09-02 | 2014-09-02 |
| 126 | 1.2.7.5 | R5 - Validación con el cliente | manual | 1.83d? | 2014-09-02 | 2014-09-02 |
| 127 | 1.2.7.6 | R6 - Definir pautas para la interfaz de usuario | manual | 1.83d? | 2014-09-02 | 2014-09-02 |
| 128 | 1.2.7.7 | R7 - Definir alcance del sistema | manual | 1.83d? | 2014-09-02 | 2014-09-02 |
| 129 | 1.2.7.8 | R8 - Definir glosario | manual | 1.83d? | 2014-09-02 | 2014-09-02 |
| 130 | 1.2.8 | **Verificación** |  | 1.83d? | 2014-09-02 | 2014-09-02 |
| 131 | 1.2.8.1 | V1 - Planificar la verificación | manual | 1.83d? | 2014-09-02 | 2014-09-02 |
| 132 | 1.2.8.2 | V3 - Planificar las pruebas de la iteración | manual | 1.83d? | 2014-09-02 | 2014-09-02 |
| 133 | 1.2.8.3 | V4 - Especificar los casos de prueba | manual | 1.83d? | 2014-09-02 | 2014-09-02 |
| 134 | 1.2.8.4 | V5 - Verificar documento | manual | 1.83d? | 2014-09-02 | 2014-09-02 |
| 135 | 1.2.8.5 | V6 - Generar entorno de prueba | manual | 1.83d? | 2014-09-02 | 2014-09-02 |
| 136 | 1.2.9 | **Comunicación** |  | 1.83d? | 2014-09-02 | 2014-09-02 |
| 137 | 1.2.9.1 | CM4 - Gestión de "Lecciones Aprendidas" | manual | 1.83d? | 2014-09-02 | 2014-09-02 |
| 138 | 1.2.9.2 | CM2 - Definición del documento de "Visión" | manual | 1.83d? | 2014-09-02 | 2014-09-02 |
| 139 | 1.2.9.3 | CM3 - Elaboración del documento "Registro de Rastreo" | manual | 1.83d? | 2014-09-02 | 2014-09-02 |
| 140 | 2 | Fin de Fase Inicial | milestone, manual | 0d | 2014-08-15 | 2014-08-15 |

| ID | WBS | Task | Type | Duration | Start | Finish |
| --- | --- | --- | --- | --- | --- | --- |
| 141 | 3 | **Fase Elaboración** |  | 51.17d | 2014-09-16 | 2014-10-13 |
| 142 | 3.1 | **Iteración 1** |  | 25.5d | 2014-09-16 | 2014-09-29 |
| 143 | 3.1.1 | **Diseño** |  | 1.83d? | 2014-09-16 | 2014-09-16 |
| 144 | 3.1.1.1 | D1 - Diseñar casos de us | manual | 1.83d? | 2014-09-16 | 2014-09-16 |
| 145 | 3.1.1.2 | D2 - Describir la arquitectura | manual | 1.83d? | 2014-09-16 | 2014-09-16 |
| 146 | 3.1.1.3 | D3 - Comunicar el diseño a los implementadores | manual | 1.83d? | 2014-09-16 | 2014-09-16 |
| 147 | 3.1.1.4 | D4 - Diseñar base de datos | manual | 1.83d? | 2014-09-16 | 2014-09-16 |
| 148 | 3.1.2 | **Gestión de Calidad** |  | 1.83d? | 2014-09-16 | 2014-09-16 |
| 149 | 3.1.2.1 | Q3 - Evaluar y ajustar el plan de SQ | manual | 1.83d? | 2014-09-16 | 2014-09-16 |
| 150 | 3.1.2.2 | Q4 - Revisión técnica formal | manual | 1.83d? | 2014-09-16 | 2014-09-16 |
| 151 | 3.1.2.3 | Q5 - Revisar las entrega | manual | 1.83d? | 2014-09-16 | 2014-09-16 |
| 152 | 3.1.2.4 | Q6 - Revisar el ajuste del proceso | manual | 1.83d? | 2014-09-16 | 2014-09-16 |
| 153 | 3.1.2.5 | Q7 - Evaluar la calidad de los productos | manual | 1.83d? | 2014-09-16 | 2014-09-16 |
| 154 | 3.1.3 | **Gestión de Configuración** |  | 1.83d? | 2014-09-16 | 2014-09-16 |
| 155 | 3.1.3.1 | C2 - Definir la línea base del proyect | manual | 1.83d? | 2014-09-16 | 2014-09-16 |
| 156 | 3.1.3.2 | C3 - Seguimiento de la línea bas | manual | 1.83d? | 2014-09-16 | 2014-09-16 |
| 157 | 3.1.3.3 | C5 - Control de cambio | manual | 1.83d? | 2014-09-16 | 2014-09-16 |
| 158 | 3.1.3.4 | C7 - Describir la versió | manual | 1.83d? | 2014-09-16 | 2014-09-16 |
| 159 | 3.1.3.5 | C8 - Escribir las notas de la versió | manual | 1.83d? | 2014-09-16 | 2014-09-16 |
| 160 | 3.1.4 | **Gestión de Proyecto** |  | 1.83d? | 2014-09-16 | 2014-09-16 |
| 161 | 3.1.4.1 | G10 - Evaluar y ajustar el plan de proyecto | manual | 1.83d? | 2014-09-16 | 2014-09-16 |
| 162 | 3.1.4.2 | G14 - Reunión evaluativa con el director del proyecto | manual | 1.83d? | 2014-09-16 | 2014-09-16 |
| 163 | 3.1.4.3 | G15 - Revisión técnica y administrativa | manual | 1.83d? | 2014-09-16 | 2014-09-16 |
| 164 | 3.1.4.4 | G16 - Reunión de responsables por área | manual | 1.83d? | 2014-09-16 | 2014-09-16 |
| 165 | 3.1.4.5 | G2 - Seguimiento del proyecto | manual | 1.83d? | 2014-09-16 | 2014-09-16 |
| 166 | 3.1.4.6 | G3 - Estimaciones y mediciones | manual | 1.83d? | 2014-09-16 | 2014-09-16 |
| 167 | 3.1.4.7 | G4 - Gestión de riesgod | manual | 1.83d? | 2014-09-16 | 2014-09-16 |
| 168 | 3.1.4.8 | G5 - Registrar esfuerz | manual | 1.83d? | 2014-09-16 | 2014-09-16 |
| 169 | 3.1.4.9 | G6 - Reunión de equipo | manual | 1.83d? | 2014-09-16 | 2014-09-16 |
| 170 | 3.1.4.10 | G7 - Elaborar acta de reunión de equipo | manual | 1.83d? | 2014-09-16 | 2014-09-16 |
| 171 | 3.1.4.11 | G8 - Reunión de seguimiento | manual | 1.83d? | 2014-09-16 | 2014-09-16 |
| 172 | 3.1.4.12 | G9 - Ajustar y controlar el desarrollo | manual | 1.83d? | 2014-09-16 | 2014-09-16 |

| ID | WBS | Task | Type | Duration | Start | Finish |
| --- | --- | --- | --- | --- | --- | --- |
| 173 | 3.1.5 | **Plan de Implantación** |  | 1.83d? | 2014-09-16 | 2014-09-16 |
| 174 | 3.1.5.1 | P9 - Definir estándares de documentación de usuario | manual | 1.83d? | 2014-09-16 | 2014-09-16 |
| 175 | 3.1.6 | **Implementación** |  | 1.83d? | 2014-09-16 | 2014-09-16 |
| 176 | 3.1.6.1 | I3 - Corregir la implementación | manual | 1.83d? | 2014-09-16 | 2014-09-16 |
| 177 | 3.1.6.2 | I4 - Planificar la integración de la iteración | manual | 1.83d? | 2014-09-16 | 2014-09-16 |
| 178 | 3.1.6.3 | I5 - Integrar el sistema | manual | 1.83d? | 2014-09-16 | 2014-09-16 |
| 179 | 3.1.6.4 | I6 - Documentación técnica | manual | 1.83d? | 2014-09-16 | 2014-09-16 |
| 180 | 3.1.6.5 | I7 - Verificación unitaria de módulo | manual | 1.83d? | 2014-09-16 | 2014-09-16 |
| 181 | 3.1.6.6 | I16 - Definir los Estilos | manual | 1.83d? | 2014-09-16 | 2014-09-16 |
| 182 | 3.1.6.7 | I14 - Crear y configurar Base de Conocimiento | manual | 1.83d? | 2014-09-16 | 2014-09-16 |
| 183 | 3.1.7 | **Requerimientos** |  | 1.83d? | 2014-09-16 | 2014-09-16 |
| 184 | 3.1.7.1 | R2 - Especificar requerimientos | manual | 1.83d? | 2014-09-16 | 2014-09-16 |
| 185 | 3.1.7.2 | R3 - Especificar casos de uso | manual | 1.83d? | 2014-09-16 | 2014-09-16 |
| 186 | 3.1.7.3 | R4 - Priorizar casos de uso | manual | 1.83d? | 2014-09-16 | 2014-09-16 |
| 187 | 3.1.7.4 | R5 - Validación con el cliente | manual | 1.83d? | 2014-09-16 | 2014-09-16 |
| 188 | 3.1.7.5 | R6 - Definir pautas para la interfaz de usuario | manual | 1.83d? | 2014-09-16 | 2014-09-16 |
| 189 | 3.1.8 | **Verificación** |  | 1.83d? | 2014-09-16 | 2014-09-16 |
| 190 | 3.1.8.1 | V2 - Evaluar y ajustar el plan de VyV | manual | 1.83d? | 2014-09-16 | 2014-09-16 |
| 191 | 3.1.8.2 | V3 - Planificar las pruebas de la iteración | manual | 1.83d? | 2014-09-16 | 2014-09-16 |
| 192 | 3.1.8.3 | V4 - Especificar los casos de prueba | manual | 1.83d? | 2014-09-16 | 2014-09-16 |
| 193 | 3.1.8.4 | V5 - Verificar documento | manual | 1.83d? | 2014-09-16 | 2014-09-16 |
| 194 | 3.1.8.5 | V6 - Generar entorno de prueba | manual | 1.83d? | 2014-09-16 | 2014-09-16 |
| 195 | 3.1.8.6 | V7 - Ejecutar las prueba | manual | 1.83d? | 2014-09-16 | 2014-09-16 |
| 196 | 3.1.8.7 | V9 - Evaluar la verificación | manual | 1.83d? | 2014-09-16 | 2014-09-16 |

| ID | WBS | Task | Type | Duration | Start | Finish |
| --- | --- | --- | --- | --- | --- | --- |
| 197 | 3.1.9 | **Comunicación** |  | 1.83d? | 2014-09-16 | 2014-09-16 |
| 198 | 3.1.9.1 | CM4: Gestión de "Lecciones Aprendidas" | manual | 1.83d? | 2014-09-16 | 2014-09-16 |
| 199 | 3.2 | **Iteración 2** |  | 25.5d | 2014-09-30 | 2014-10-13 |
| 200 | 3.2.1 | **Diseño** |  | 1.83d? | 2014-09-30 | 2014-09-30 |
| 201 | 3.2.1.1 | D1 - Diseñar casos de us | manual | 1.83d? | 2014-09-30 | 2014-09-30 |
| 202 | 3.2.1.2 | D2 - Describir la arquitectura | manual | 1.83d? | 2014-09-30 | 2014-09-30 |
| 203 | 3.2.1.3 | D3 - Comunicar el diseño a los implementadores | manual | 1.83d? | 2014-09-30 | 2014-09-30 |
| 204 | 3.2.1.4 | D4 - Diseñar base de datos | manual | 1.83d? | 2014-09-30 | 2014-09-30 |
| 205 | 3.2.2 | **Gestión de Calidad** |  | 1.83d? | 2014-09-30 | 2014-09-30 |
| 206 | 3.2.2.1 | Q3 - Evaluar y ajustar el plan de SQ | manual | 1.83d? | 2014-09-30 | 2014-09-30 |
| 207 | 3.2.2.2 | Q4 - Revisión técnica formal | manual | 1.83d? | 2014-09-30 | 2014-09-30 |
| 208 | 3.2.2.3 | Q5 - Revisar las entrega | manual | 1.83d? | 2014-09-30 | 2014-09-30 |
| 209 | 3.2.2.4 | Q6 - Revisar el ajuste del proceso | manual | 1.83d? | 2014-09-30 | 2014-09-30 |
| 210 | 3.2.2.5 | Q7 - Evaluar la calidad de los productos | manual | 1.83d? | 2014-09-30 | 2014-09-30 |
| 211 | 3.2.3 | **Gestión de Configuración** |  | 1.83d? | 2014-09-30 | 2014-09-30 |
| 212 | 3.2.3.1 | C3 - Seguimiento de la línea base | manual | 1.83d? | 2014-09-30 | 2014-09-30 |
| 213 | 3.2.3.2 | C5 - Control de cambios | manual | 1.83d? | 2014-09-30 | 2014-09-30 |
| 214 | 3.2.3.3 | C7 - Describir la versión | manual | 1.83d? | 2014-09-30 | 2014-09-30 |
| 215 | 3.2.3.4 | C8 - Escribir las notas de la versión | manual | 1.83d? | 2014-09-30 | 2014-09-30 |
| 216 | 3.2.4 | **Gestión de Proyecto** |  | 1.83d? | 2014-09-30 | 2014-09-30 |
| 217 | 3.2.4.1 | G10 - Evaluar y ajustar el plan de proyecto | manual | 1.83d? | 2014-09-30 | 2014-09-30 |
| 218 | 3.2.4.2 | G13 - Evaluar la fase | manual | 1.83d? | 2014-09-30 | 2014-09-30 |
| 219 | 3.2.4.3 | G15 - Revisión técnica y administrativa | manual | 1.83d? | 2014-09-30 | 2014-09-30 |
| 220 | 3.2.4.4 | G16 - Reunión de responsables por área | manual | 1.83d? | 2014-09-30 | 2014-09-30 |
| 221 | 3.2.4.5 | G18 - Presentación al director de proyecto | manual | 1.83d? | 2014-09-30 | 2014-09-30 |
| 222 | 3.2.4.6 | G2 - Seguimiento del proyecto | manual | 1.83d? | 2014-09-30 | 2014-09-30 |
| 223 | 3.2.4.7 | G3 - Estimaciones y mediciones | manual | 1.83d? | 2014-09-30 | 2014-09-30 |
| 224 | 3.2.4.8 | G4 - Gestión de riesgos | manual | 1.83d? | 2014-09-30 | 2014-09-30 |
| 225 | 3.2.4.9 | G5 - Registrar esfuerzo | manual | 1.83d? | 2014-09-30 | 2014-09-30 |
| 226 | 3.2.4.10 | G6 - Reunión de equipo | manual | 1.83d? | 2014-09-30 | 2014-09-30 |
| 227 | 3.2.4.11 | G7 - Elaborar acta de reunión de equipo | manual | 1.83d? | 2014-09-30 | 2014-09-30 |
| 228 | 3.2.4.12 | G8 - Reunión de seguimiento | manual | 1.83d? | 2014-09-30 | 2014-09-30 |
| 229 | 3.2.4.13 | G9 - Ajustar y controlar el desarrollo | manual | 1.83d? | 2014-09-30 | 2014-09-30 |

| ID | WBS | Task | Type | Duration | Start | Finish |
| --- | --- | --- | --- | --- | --- | --- |
| 230 | 3.2.5 | **Plan de Implantación** |  | 1.83d? | 2014-09-30 | 2014-09-30 |
| 231 | 3.2.5.1 | P2 - Documentación de usuario | manual | 1.83d? | 2014-09-30 | 2014-09-30 |
| 232 | 3.2.6 | **Implementación** |  | 1.83d? | 2014-09-30 | 2014-09-30 |
| 233 | 3.2.6.1 | I3 - Corregir la implementación | manual | 1.83d? | 2014-09-30 | 2014-09-30 |
| 234 | 3.2.6.2 | I4 - Planificar la integración de la iteración | manual | 1.83d? | 2014-09-30 | 2014-09-30 |
| 235 | 3.2.6.3 | I5 - Integrar el sistema | manual | 1.83d? | 2014-09-30 | 2014-09-30 |
| 236 | 3.2.6.4 | I6 - Documentación técnica | manual | 1.83d? | 2014-09-30 | 2014-09-30 |
| 237 | 3.2.6.5 | I7 - Verificación unitaria de módulo | manual | 1.83d? | 2014-09-30 | 2014-09-30 |
| 238 | 3.2.7 | **Requerimientos** |  | 1.83d? | 2014-09-30 | 2014-09-30 |
| 239 | 3.2.7.1 | R2 - Especificar requerimiento | manual | 1.83d? | 2014-09-30 | 2014-09-30 |
| 240 | 3.2.7.2 | R5 - Validación con el cliente | manual | 1.83d? | 2014-09-30 | 2014-09-30 |
| 241 | 3.2.8 | **Verificación** |  | 1.83d? | 2014-09-30 | 2014-09-30 |
| 242 | 3.2.8.1 | V2 - Evaluar y ajustar el plan de VyV | manual | 1.83d? | 2014-09-30 | 2014-09-30 |
| 243 | 3.2.8.2 | V3 - Planificar las pruebas de la iteración | manual | 1.83d? | 2014-09-30 | 2014-09-30 |
| 244 | 3.2.8.3 | V4 - Especificar los casos de prueba | manual | 1.83d? | 2014-09-30 | 2014-09-30 |
| 245 | 3.2.8.4 | V5 - Verificar documento | manual | 1.83d? | 2014-09-30 | 2014-09-30 |
| 246 | 3.2.8.5 | V6 - Generar entorno de prueba | manual | 1.83d? | 2014-09-30 | 2014-09-30 |
| 247 | 3.2.8.6 | V7 - Ejecutar las pruebas | manual | 1.83d? | 2014-09-30 | 2014-09-30 |
| 248 | 3.2.8.7 | V9 - Evaluar la verificación | manual | 1.83d? | 2014-09-30 | 2014-09-30 |
| 249 | 3.2.8.8 | V11 - Ejecutar pruebas no funcionales | manual | 1.83d? | 2014-09-30 | 2014-09-30 |
| 250 | 3.2.9 | **Comunicación** |  | 1.83d? | 2014-09-30 | 2014-09-30 |
| 251 | 3.2.9.1 | CM4: Gestión de "Lecciones Aprendidas" | manual | 1.83d? | 2014-09-30 | 2014-09-30 |
| 252 | 4 | Fin de Fase Elaboración | milestone, manual | 0d | 2014-09-29 | 2014-09-29 |
| 253 | 5 | **Fase Construcción** |  | 51.17d | 2014-10-14 | 2014-11-10 |
| 254 | 5.1 | **Iteración 1** |  | 25.5d | 2014-10-14 | 2014-10-27 |
| 255 | 5.1.1 | **Diseño** |  | 1.83d | 2014-10-14 | 2014-10-14 |
| 256 | 5.1.1.1 | D1 - Diseñar casos de uso | manual | 1.83d | 2014-10-14 | 2014-10-14 |
| 257 | 5.1.1.2 | D3 - Comunicar el diseño a los implementadores | manual | 12.67d | 2014-10-21 | 2014-10-27 |
| 258 | 5.1.1.3 | D4 - Diseñar base de datos | manual | 1.83d? | 2014-10-14 | 2014-10-14 |

| ID | WBS | Task | Type | Duration | Start | Finish |
| --- | --- | --- | --- | --- | --- | --- |
| 259 | 5.1.2 | **Gestión de Calidad** |  | 1.83d? | 2014-10-14 | 2014-10-14 |
| 260 | 5.1.2.1 | Q4 - Revisión técnica formal | manual | 1.83d? | 2014-10-14 | 2014-10-14 |
| 261 | 5.1.2.2 | Q5 - Revisar las entregas | manual | 1.83d? | 2014-10-14 | 2014-10-14 |
| 262 | 5.1.2.3 | Q6 - Revisar el ajuste del proceso | manual | 1.83d? | 2014-10-14 | 2014-10-14 |
| 263 | 5.1.2.4 | Q7 - Evaluar la calidad de los productos | manual | 1.83d? | 2014-10-14 | 2014-10-14 |
| 264 | 5.1.3 | **Gestión de Configuración** |  | 1.83d? | 2014-10-14 | 2014-10-14 |
| 265 | 5.1.3.1 | C3 - Seguimiento de la línea base | manual | 1.83d? | 2014-10-14 | 2014-10-14 |
| 266 | 5.1.3.2 | C5 - Control de cambios | manual | 1.83d? | 2014-10-14 | 2014-10-14 |
| 267 | 5.1.3.3 | C7 - Describir la versión | manual | 1.83d? | 2014-10-14 | 2014-10-14 |
| 268 | 5.1.3.4 | C8 - Escribir las notas de la versión | manual | 1.83d? | 2014-10-14 | 2014-10-14 |
| 269 | 5.1.4 | **Gestión de Proyecto** |  | 1.83d? | 2014-10-14 | 2014-10-14 |
| 270 | 5.1.4.1 | G10 - Evaluar y ajustar el plan de proyecto | manual | 1.83d? | 2014-10-14 | 2014-10-14 |
| 271 | 5.1.4.2 | G14 - Reunión evaluativa con el director del proyecto | manual | 1.83d? | 2014-10-14 | 2014-10-14 |
| 272 | 5.1.4.3 | G15 - Revisión técnica y administrativa | manual | 1.83d? | 2014-10-14 | 2014-10-14 |
| 273 | 5.1.4.4 | G16 - Reunión de responsables por área | manual | 1.83d? | 2014-10-14 | 2014-10-14 |
| 274 | 5.1.4.5 | G2 - Seguimiento del proyecto | manual | 1.83d? | 2014-10-14 | 2014-10-14 |
| 275 | 5.1.4.6 | G4 - Gestión de riesgo | manual | 1.83d? | 2014-10-14 | 2014-10-14 |
| 276 | 5.1.4.7 | G5 - Registrar esfuerzo | manual | 1.83d? | 2014-10-14 | 2014-10-14 |
| 277 | 5.1.4.8 | G6 - Reunión de equipo | manual | 1.83d? | 2014-10-14 | 2014-10-14 |
| 278 | 5.1.4.9 | G7 - Elaborar acta de reunión de equipo | manual | 1.83d? | 2014-10-14 | 2014-10-14 |
| 279 | 5.1.4.10 | G8 - Reunión de seguimiento | manual | 1.83d? | 2014-10-14 | 2014-10-14 |
| 280 | 5.1.4.11 | G9 - Ajustar y controlar el desarrollo | manual | 1.83d? | 2014-10-14 | 2014-10-14 |
| 281 | 5.1.5 | **Plan de Implantación** |  | 1.83d? | 2014-10-14 | 2014-10-14 |
| 282 | 5.1.5.1 | P1 - Planificar la implantación | manual | 1.83d? | 2014-10-14 | 2014-10-14 |
| 283 | 5.1.5.2 | P10 - Desarrollar los materiales para capacitación | manual | 1.83d? | 2014-10-14 | 2014-10-14 |
| 284 | 5.1.5.3 | P2 - Documentación de usuario | manual | 1.83d? | 2014-10-14 | 2014-10-14 |
| 285 | 5.1.5.4 | P7 - Verificar la versión del producto a liberar | manual | 1.83d? | 2014-10-14 | 2014-10-14 |

| ID | WBS | Task | Type | Duration | Start | Finish |
| --- | --- | --- | --- | --- | --- | --- |
| 286 | 5.1.6 | **Implementación** |  | 1.83d? | 2014-10-14 | 2014-10-14 |
| 287 | 5.1.6.1 | I3 - Corregir la implementación | manual | 1.83d? | 2014-10-14 | 2014-10-14 |
| 288 | 5.1.6.2 | I4 - Planificar la integración de la iteración | manual | 1.83d? | 2014-10-14 | 2014-10-14 |
| 289 | 5.1.6.3 | I5 - Integrar el sistema | manual | 1.83d? | 2014-10-14 | 2014-10-14 |
| 290 | 5.1.6.4 | I6 - Documentación técnica | manual | 1.83d? | 2014-10-14 | 2014-10-14 |
| 291 | 5.1.6.5 | I7 - Verificación unitaria de módulo | manual | 1.83d? | 2014-10-14 | 2014-10-14 |
| 292 | 5.1.7 | **Requerimientos** |  | 1.83d? | 2014-10-14 | 2014-10-14 |
| 293 | 5.1.7.1 | R2 - Especificar requerimiento | manual | 1.83d? | 2014-10-14 | 2014-10-14 |
| 294 | 5.1.7.2 | R5 - Validación con el cliente | manual | 1.83d? | 2014-10-14 | 2014-10-14 |
| 295 | 5.1.8 | **Verificación** |  | 1.83d? | 2014-10-14 | 2014-10-14 |
| 296 | 5.1.8.1 | V3 - Planificar las pruebas de la iteració | manual | 1.83d? | 2014-10-14 | 2014-10-14 |
| 297 | 5.1.8.2 | V4 - Especificar los casos de prueba | manual | 1.83d? | 2014-10-14 | 2014-10-14 |
| 298 | 5.1.8.3 | V5 - Verificar documento | manual | 1.83d? | 2014-10-14 | 2014-10-14 |
| 299 | 5.1.8.4 | V6 - Generar entorno de prueba | manual | 1.83d? | 2014-10-14 | 2014-10-14 |
| 300 | 5.1.8.5 | V7 - Ejecutar las prueba | manual | 1.83d? | 2014-10-14 | 2014-10-14 |
| 301 | 5.1.8.6 | V9 - Evaluar la verificación | manual | 1.83d? | 2014-10-14 | 2014-10-14 |
| 302 | 5.1.9 | **Comunicación** |  | 1.83d? | 2014-10-14 | 2014-10-14 |
| 303 | 5.1.9.1 | CM4 - Gestión de "Lecciones Aprendidas" | manual | 1.83d? | 2014-10-14 | 2014-10-14 |
| 304 | 5.2 | **Iteración 2** |  | 25.5d | 2014-10-28 | 2014-11-10 |
| 305 | 5.2.1 | **Gestión de Calidad** |  | 1.83d? | 2014-10-28 | 2014-10-28 |
| 306 | 5.2.1.1 | Q3 - Evaluar y ajustar el plan de SQ | manual | 1.83d? | 2014-10-28 | 2014-10-28 |
| 307 | 5.2.1.2 | Q4 - Revisión técnica formal | manual | 1.83d? | 2014-10-28 | 2014-10-28 |
| 308 | 5.2.1.3 | Q5 - Revisar las entrega | manual | 1.83d? | 2014-10-28 | 2014-10-28 |
| 309 | 5.2.1.4 | Q6 - Revisar el ajuste del proceso | manual | 1.83d? | 2014-10-28 | 2014-10-28 |
| 310 | 5.2.1.5 | Q7 - Evaluar la calidad de los productos | manual | 1.83d? | 2014-10-28 | 2014-10-28 |

| ID | WBS | Task | Type | Duration | Start | Finish |
| --- | --- | --- | --- | --- | --- | --- |
| 311 | 5.2.2 | **Gestión de Configuración** |  | 1.83d? | 2014-10-28 | 2014-10-28 |
| 312 | 5.2.2.1 | C3 - Seguimiento de la línea base | manual | 1.83d? | 2014-10-28 | 2014-10-28 |
| 313 | 5.2.2.2 | C5 - Control de cambio | manual | 1.83d? | 2014-10-28 | 2014-10-28 |
| 314 | 5.2.2.3 | C7 - Describir la versión | manual | 1.83d? | 2014-10-28 | 2014-10-28 |
| 315 | 5.2.2.4 | C8 - Escribir las notas de la versión | manual | 1.83d? | 2014-10-28 | 2014-10-28 |
| 316 | 5.2.3 | **Gestión de Proyecto** |  | 1.83d? | 2014-10-28 | 2014-10-28 |
| 317 | 5.2.3.1 | G10 - Evaluar y ajustar el plan de proyecto | manual | 1.83d? | 2014-10-28 | 2014-10-28 |
| 318 | 5.2.3.2 | G13 - Evaluar la fase | manual | 1.83d? | 2014-10-28 | 2014-10-28 |
| 319 | 5.2.3.3 | G15 - Revisión técnica y administrativa | manual | 1.83d? | 2014-10-28 | 2014-10-28 |
| 320 | 5.2.3.4 | G16 - Reunión de responsables por área | manual | 1.83d? | 2014-10-28 | 2014-10-28 |
| 321 | 5.2.3.5 | G18 - Presentación al director de proyecto | manual | 1.83d? | 2014-10-28 | 2014-10-28 |
| 322 | 5.2.3.6 | G2 - Seguimiento del proyecto | manual | 1.83d? | 2014-10-28 | 2014-10-28 |
| 323 | 5.2.3.7 | G4 - Gestión de riesgo | manual | 1.83d? | 2014-10-28 | 2014-10-28 |
| 324 | 5.2.3.8 | G5 - Registrar esfuerzo | manual | 1.83d? | 2014-10-28 | 2014-10-28 |
| 325 | 5.2.3.9 | G6 - Reunión de equipo | manual | 1.83d? | 2014-10-28 | 2014-10-28 |
| 326 | 5.2.3.10 | G7 - Elaborar acta de reunión de equipo | manual | 1.83d? | 2014-10-28 | 2014-10-28 |
| 327 | 5.2.3.11 | G8 - Reunión de seguimiento | manual | 1.83d? | 2014-10-28 | 2014-10-28 |
| 328 | 5.2.3.12 | G9 - Ajustar y controlar el desarrollo | manual | 1.83d? | 2014-10-28 | 2014-10-28 |
| 329 | 5.2.4 | **Plan de Implantación** |  | 1.83d? | 2014-10-28 | 2014-10-28 |
| 330 | 5.2.4.1 | P1 - Planificar la implantación | manual | 1.83d? | 2014-10-28 | 2014-10-28 |
| 331 | 5.2.4.2 | P10 - Desarrollar los materiales para capacitación | manual | 1.83d? | 2014-10-28 | 2014-10-28 |
| 332 | 5.2.4.3 | P2 - Documentación de usuario | manual | 1.83d? | 2014-10-28 | 2014-10-28 |
| 333 | 5.2.4.4 | P3 - Elaborar la preseentación del sistema para el cliente | manual | 1.83d? | 2014-10-28 | 2014-10-28 |
| 334 | 5.2.4.5 | P7 - Verificar la versión del producto a liberar | manual | 1.83d? | 2014-10-28 | 2014-10-28 |
| 335 | 5.2.4.6 | P8 - Pruebas beta del producto | manual | 1.83d? | 2014-10-28 | 2014-10-28 |

| ID | WBS | Task | Type | Duration | Start | Finish | Total slack | Constraint |
| --- | --- | --- | --- | --- | --- | --- | --- | --- |
| 336 | 5.2.5 | **Implementación** |  | 1.83d? | 2014-10-28 | 2014-10-28 |  |  |
| 337 | 5.2.5.1 | I3 - Corregir la implementación | manual | 1.83d? | 2014-10-28 | 2014-10-28 |  |  |
| 338 | 5.2.5.2 | I5 - Integrar el sistema | manual | 1.83d? | 2014-10-28 | 2014-10-28 |  |  |
| 339 | 5.2.5.3 | I6 - Documentación técnica | manual | 1.83d? | 2014-10-28 | 2014-10-28 |  |  |
| 340 | 5.2.5.4 | I7 - Verificación unitaria de módulo | manual | 1.83d? | 2014-10-28 | 2014-10-28 |  |  |
| 341 | 5.2.6 | **Verificación** |  | 1.83d? | 2014-10-28 | 2014-10-28 |  |  |
| 342 | 5.2.6.1 | V2 - Evaluar y ajustar el plan de Vy | manual | 1.83d? | 2014-10-28 | 2014-10-28 |  |  |
| 343 | 5.2.6.2 | V3 - Planificar las pruebas de la iteració | manual | 1.83d? | 2014-10-28 | 2014-10-28 |  |  |
| 344 | 5.2.6.3 | V4 - Especificar los casos de prueba | manual | 1.83d? | 2014-10-28 | 2014-10-28 |  |  |
| 345 | 5.2.6.4 | V5 - Verificar documento | manual | 1.83d? | 2014-10-28 | 2014-10-28 |  |  |
| 346 | 5.2.6.5 | V6 - Generar entorno de prueba | manual | 1.83d? | 2014-10-28 | 2014-10-28 |  |  |
| 347 | 5.2.6.6 | V7 - Ejecutar las prueba | manual | 1.83d? | 2014-10-28 | 2014-10-28 |  |  |
| 348 | 5.2.6.7 | V9 - Evaluar la verificación | manual | 1.83d? | 2014-10-28 | 2014-10-28 |  |  |
| 349 | 5.2.7 | **Comunicación** |  | 1.83d? | 2014-10-28 | 2014-10-28 |  |  |
| 350 | 5.2.7.1 | CM4 - Gestión de "Lecciones Aprendidas" | manual | 1.83d? | 2014-10-28 | 2014-10-28 |  |  |
| 351 | 6 | Fin de Fase | milestone | 0d | 2014-11-10 | 2014-11-10 | 27.33d | start no earlier than 2014-11-10 |
| 352 | 7 | **Fase Transición** |  | 25.5d | 2014-11-11 | 2014-11-24 |  |  |
| 353 | 7.1 | **Iteración 1** |  | 25.5d | 2014-11-11 | 2014-11-24 |  |  |
| 354 | 7.1.1 | **Satisfacción del Cliente** |  | 12.67d | 2014-11-11 | 2014-11-17 |  |  |
| 355 | 7.1.1.1 | CU2 - Seguimiento de satisfacción del cliente | manual | 1.83d | 2014-11-11 | 2014-11-11 |  |  |
| 356 | 7.1.2 | **Gestión de Calidad** |  | 12.67d | 2014-11-18 | 2014-11-24 |  |  |
| 357 | 7.1.2.1 | Q5 - Revisar las entregas | manual | 1.83d | 2014-11-18 | 2014-11-18 |  |  |
| 358 | 7.1.2.2 | Q7 - Evaluar la calidad de los productos | manual | 1.83d | 2014-11-18 | 2014-11-18 |  |  |
| 359 | 7.1.2.3 | Q8 - Realizar el informe final de SQA | manual | 1.83d | 2014-11-18 | 2014-11-18 |  |  |

| ID | WBS | Task | Type | Duration | Start | Finish | Total slack |
| --- | --- | --- | --- | --- | --- | --- | --- |
| 360 | 7.1.3 | **Gestión de Configuración** |  | 1.83d | 2014-11-11 | 2014-11-11 | 0d |
| 361 | 7.1.3.1 | C3 - Seguimiento de la línea base | manual | 1.83d | 2014-11-11 | 2014-11-11 |  |
| 362 | 7.1.3.2 | C6 - Realizar el informe final de SCM | manual | 1.83d | 2014-11-11 | 2014-11-11 |  |
| 363 | 7.1.3.3 | C7 - Describir la versión | manual | 1.83d | 2014-11-11 | 2014-11-11 |  |
| 364 | 7.1.3.4 | C8 - Escribir las notas de la versión | manual | 1.83d | 2014-11-11 | 2014-11-11 |  |
| 365 | 7.1.4 | **Gestión de Proyecto** |  | 1.83d | 2014-11-11 | 2014-11-11 | 0d |
| 366 | 7.1.4.1 | G11 - Realizar el informe final del proyecto | manual | 1.83d | 2014-11-11 | 2014-11-11 |  |
| 367 | 7.1.4.2 | G12 - Preparar el cierre del proyecto | manual | 1.83d | 2014-11-11 | 2014-11-11 |  |
| 368 | 7.1.4.3 | G13 - Evaluar la fase | manual | 1.83d | 2014-11-11 | 2014-11-11 |  |
| 369 | 7.1.4.4 | G14 - Reunión evaluativa con el director del proyecto | manual | 1.83d | 2014-11-11 | 2014-11-11 |  |
| 370 | 7.1.4.5 | G15 - Revisión técnica y administrativa | manual | 1.83d | 2014-11-11 | 2014-11-11 |  |
| 371 | 7.1.4.6 | G18 - Presentación al director de proyecto | manual | 1.83d | 2014-11-11 | 2014-11-11 |  |
| 372 | 7.1.4.7 | G2 - Seguimiento del proyecto | manual | 1.83d | 2014-11-11 | 2014-11-11 |  |
| 373 | 7.1.4.8 | G5 - Registrar esfuerzo | manual | 1.83d | 2014-11-11 | 2014-11-11 |  |
| 374 | 7.1.4.9 | G6 - Reunión de equipo | manual | 1.83d | 2014-11-11 | 2014-11-11 |  |
| 375 | 7.1.4.10 | G7 - Elaborar acta de reunión de equipo | manual | 1.83d | 2014-11-11 | 2014-11-11 |  |
| 376 | 7.1.4.11 | G8 - Reunión de seguimiento | manual | 1.83d | 2014-11-11 | 2014-11-11 |  |
| 377 | 7.1.5 | **Plan de Implantación** |  | 1.83d | 2014-11-11 | 2014-11-11 | 0d |
| 378 | 7.1.5.1 | P10 - Desarrollar los materiales para capacitación | manual | 1.83d | 2014-11-11 | 2014-11-11 |  |
| 379 | 7.1.5.2 | P11 - Preparar el entorno de capacitación | manual | 1.83d | 2014-11-11 | 2014-11-11 |  |
| 380 | 7.1.5.3 | P12 - Capacitación | manual | 1.83d | 2014-11-11 | 2014-11-11 |  |
| 381 | 7.1.5.4 | P2 - Documentación de usuario | manual | 1.83d | 2014-11-11 | 2014-11-11 |  |
| 382 | 7.1.5.5 | P4 - Producir la versión del producto a liberar | manual | 1.83d | 2014-11-11 | 2014-11-11 |  |
| 383 | 7.1.5.6 | P5 - Puesta en producción | manual | 1.83d | 2014-11-11 | 2014-11-11 |  |
| 384 | 7.1.5.7 | P6 - Realizar las pruebas de aceptación | manual | 1.83d | 2014-11-11 | 2014-11-11 |  |
| 385 | 7.1.5.8 | P7 - Verificar la versión del producto a liberar | manual | 1.83d | 2014-11-11 | 2014-11-11 |  |
| 386 | 7.1.5.9 | P8 - Pruebas beta del producto | manual | 1.83d | 2014-11-11 | 2014-11-11 |  |

| ID | WBS | Task | Type | Duration | Start | Finish | Total slack |
| --- | --- | --- | --- | --- | --- | --- | --- |
| 387 | 7.1.6 | **Implementación** |  | 1.83d | 2014-11-11 | 2014-11-11 | 0d |
| 388 | 7.1.6.1 | I6 - Documentación técnica | manual | 1.83d | 2014-11-11 | 2014-11-11 |  |
| 389 | 7.1.7 | **Verificación** |  | 1.83d | 2014-11-11 | 2014-11-11 | 0d |
| 390 | 7.1.7.1 | V10 - Realizar el informe final de verificación | manual | 1.83d | 2014-11-11 | 2014-11-11 |  |
| 391 | 7.1.7.2 | V6 - Generar entorno de prueba | manual | 1.83d | 2014-11-11 | 2014-11-11 |  |
| 392 | 7.1.7.3 | V7 - Ejecutar las prueba | manual | 1.83d | 2014-11-11 | 2014-11-11 |  |
| 393 | 7.1.7.4 | V8 - Pruebas del sistema | manual | 1.83d | 2014-11-11 | 2014-11-11 |  |
| 394 | 7.1.7.5 | V9 - Evaluar la verificación | manual | 1.83d | 2014-11-11 | 2014-11-11 |  |
| 395 | 7.1.8 | **Comunicación** |  | 1.83d? | 2014-11-11 | 2014-11-11 | 0d |
| 396 | 7.1.8.1 | CM4 - Gestión de "Lecciones Aprendidas" | manual | 1.83d? | 2014-11-11 | 2014-11-11 |  |
| 397 | 7.2 | Fin de Fase | milestone, manual | 0d | 2014-11-11 | 2014-11-11 |  |
| 398 | 7.3 | Fin de proyecto | milestone, manual | 0d | 2014-11-11 | 2014-11-11 |  |
